# Tradeshow-plan

Schedule from MS Project, 2009-02-20 to 2009-05-28.
Trade show setup, execution, project close
Theprojectdiva.com

## Calendars

- Standard: Mon-Fri 08:00-12:00, 13:00-17:00; Sat-Sun off. Exceptions (off unless hours are given): 2009-05-16 to 2009-05-17 08:00-12:00, 13:00-17:00.

## Resources

| Resource |
| --- |
| Show Staff |
| Project Manager |
| Project Team |
| Project Sponsor |
| Marketing |
| Sales Manager |
| Accounting |
| Inventory |
| Technical |
| Administrative |
| Vendors |

## Schedule

| ID | WBS | Task | Duration | Start | Finish | Predecessors | Total slack | Free slack | Constraint | Resources | Work |
| --- | --- | --- | --- | --- | --- | --- | --- | --- | --- | --- | --- |
| 1 | 1 | **Tradeshow Planning, Execution and Project Closure** | 71.75d | 2009-02-20 | 2009-05-28 |  | 0d |  |  |  | 1095.67h |
| 3 | 1.1 | **Planning** | 15.58d | 2009-02-20 | 2009-03-13 |  | 14.75d |  |  |  | 57.33h |
| 4 | 1.1.1 | Identify project goals | 1.08d | 2009-02-20 | 2009-02-23 |  | 14.75d | 0d | start no earlier than 2009-02-20 | Project Sponsor [50%]; Project Manager [50%] | 8.67h |
| 5 | 1.1.2 | Identify project participants | 1.08d | 2009-02-20 | 2009-02-23 |  | 70.67d |  | start no earlier than 2009-02-20 | Project Manager | 8.67h |
| 6 | 1.1.3 | Develop preliminary budget | 1.08d | 2009-02-23 | 2009-02-24 |  | 69.67d |  | start no earlier than 2009-02-23 | Project Manager | 8.67h |
| 7 | 1.1.4 | Formal budgeting | 1.17d | 2009-03-11 | 2009-03-12 | 11 | 57.17d |  | start no earlier than 2009-02-20 | Project Manager | 9.33h |
| 8 | 1.1.5 | Show marketing plan | 2.17d | 2009-03-11 | 2009-03-13 | 23 | 14.75d | 0d |  | Marketing [90%]; Project Manager [10%] | 17.33h |
| 9 | 1.1.6 | Lead tracking plan | 0.58d | 2009-02-20 | 2009-02-20 |  | 71.17d |  | start no earlier than 2009-02-20 | Sales Manager | 4.67h |
| 11 | 1.2 | **Venue Selection** | 12.33d | 2009-02-23 | 2009-03-11 |  | 14.75d | 0d |  |  | 159.33h |
| 12 | 1.2.1 | **Define basic venue requirements** | 1.08d | 2009-02-23 | 2009-02-24 | 4 | 67.33d |  |  |  | 39.33h |
| 13 | 1.2.1.1 | Location & accessibility | 1.08d | 2009-02-23 | 2009-02-24 |  | 67.33d |  | start no earlier than 2009-02-20 | Project Team | 8.67h |
| 14 | 1.2.1.2 | Voice & data & electrical | 1.08d | 2009-02-23 | 2009-02-24 |  | 67.33d |  | start no earlier than 2009-02-20 | Project Team | 8.67h |
| 15 | 1.2.1.3 | **Other technical** | 1.08d | 2009-02-23 | 2009-02-24 |  | 67.33d |  |  |  | 8.67h |
| 16 | 1.2.1.3.1 | Audio/visual | 1.08d | 2009-02-23 | 2009-02-24 |  | 67.33d |  | start no earlier than 2009-02-20 | Project Team | 8.67h |
| 17 | 1.2.1.4 | Other non-technical | 1.08d | 2009-02-23 | 2009-02-24 |  | 67.33d |  | start no earlier than 2009-02-20 | Project Team | 8.67h |
| 18 | 1.2.1.5 | Security | 0.58d | 2009-02-23 | 2009-02-23 |  | 67.83d |  | start no earlier than 2009-02-20 | Project Team | 4.67h |
| 19 | 1.2.2 | **Identify potential shows** | 12.33d | 2009-02-23 | 2009-03-11 |  | 14.75d | 0d |  |  | 120h |
| 20 | 1.2.2.1 | Research shows | 5.5d | 2009-02-23 | 2009-03-02 | 4 | 14.75d | 0d | start no earlier than 2009-02-20 | Project Team | 44h |
| 21 | 1.2.2.2 | Obtain show manual | 3.67d | 2009-03-02 | 2009-03-06 | 20 | 14.75d | 0d | start no earlier than 2009-02-20 | Project Team | 29.33h |
| 22 | 1.2.2.3 | Team review of show materials | 2.33d | 2009-03-06 | 2009-03-10 | 21 | 46d |  | start no earlier than 2009-02-20 | Project Team | 18.67h |
| 23 | 1.2.2.4 | **Formal show review and selection process** | 1.17d | 2009-03-10 | 2009-03-11 | 21FS+2d | 14.75d | 0d |  |  | 28h |
| 24 | 1.2.2.4.1 | Demographic analysis | 1.17d | 2009-03-10 | 2009-03-11 |  | 14.75d |  | start no earlier than 2009-02-20 | Project Team [50%]; Marketing [50%] | 9.33h |
| 25 | 1.2.2.4.2 | Market impact analysis | 1.17d | 2009-03-10 | 2009-03-11 |  | 14.75d |  |  | Project Team [20%]; Marketing [80%] | 9.33h |
| 26 | 1.2.2.4.3 | Competitor analysis | 1.17d | 2009-03-10 | 2009-03-11 |  | 14.75d |  |  | Project Team | 9.33h |

Notes:
- 21: The show manual provides important information such as floor plan, exhibit specifications, available services, special security provisions, schedules, etc.

| ID | WBS | Task | Type | Duration | Start | Finish | Predecessors | Total slack | Free slack | Constraint | Resources | Work |
| --- | --- | --- | --- | --- | --- | --- | --- | --- | --- | --- | --- | --- |
| 27 | 1.2.3 | **Select Venue** |  | 0d | 2009-03-11 | 2009-03-11 | 19 | 45.17d | 2.17d |  |  |  |
| 28 | 1.2.3.1 | Sign agreements | milestone | 0d | 2009-03-11 | 2009-03-11 |  | 45.17d | 0d | start no earlier than 2009-02-20 | Project Sponsor |  |
| 29 | 1.2.3.2 | Define venue point of contact | milestone | 0d | 2009-03-11 | 2009-03-11 |  | 45.17d |  |  | Project Manager |  |
| 30 | 1.2.3.3 | Payment | milestone | 0d | 2009-03-11 | 2009-03-11 | 28 | 45.17d |  |  | Accounting |  |
| 32 | 1.3 | **Show Materials** |  | 34.83d | 2009-03-06 | 2009-04-24 |  | 20.08d |  |  |  | 600.67h |
| 33 | 1.3.1 | **Define required materials** |  | 9.5d | 2009-03-06 | 2009-03-19 |  | 14.75d | 0d |  |  | 284h |
| 34 | 1.3.1.1 | **Review show manual** |  | 1.08d | 2009-03-06 | 2009-03-09 | 21 | 23.17d |  |  |  | 30.67h |
| 35 | 1.3.1.1.1 | Booth specifications |  | 1.08d | 2009-03-06 | 2009-03-09 |  | 23.17d |  | start no earlier than 2009-02-20 | Project Team; Marketing | 17.33h |
| 36 | 1.3.1.1.2 | Electrical, data, voice connectivity |  | 0.58d | 2009-03-06 | 2009-03-06 |  | 23.67d |  | start no earlier than 2009-02-20 | Project Team [50%]; Marketing [40%]; Technical [10%] | 4.67h |
| 37 | 1.3.1.1.3 | Venue promotional materials |  | 1.08d | 2009-03-06 | 2009-03-09 |  | 23.17d |  | start no earlier than 2009-02-20 | Project Team [10%]; Marketing [90%] | 8.67h |
| 38 | 1.3.1.2 | **Review show marketing plan** |  | 1.08d | 2009-03-13 | 2009-03-16 | 8 | 17.83d | 0d |  |  | 17.33h |
| 39 | 1.3.1.2.1 | Demographics analysis |  | 1.08d | 2009-03-13 | 2009-03-16 |  | 17.83d |  | start no earlier than 2009-02-20 | Project Team [10%]; Marketing [90%] | 8.67h |
| 40 | 1.3.1.2.2 | Attendance expectations |  | 1.08d | 2009-03-13 | 2009-03-16 |  | 17.83d |  | start no earlier than 2009-02-20 | Project Team [10%]; Marketing [90%] | 8.67h |
| 41 | 1.3.1.3 | Technical product demos |  | 3.83d | 2009-03-13 | 2009-03-19 | 8 | 15.08d |  | start no earlier than 2009-02-20 | Project Team; Technical | 61.33h |
| 42 | 1.3.1.4 | Product brochures |  | 4.17d | 2009-03-13 | 2009-03-19 | 8 | 14.75d |  | start no earlier than 2009-02-20 | Project Team [20%]; Marketing [80%] | 33.33h |
| 43 | 1.3.1.5 | Show give-aways |  | 1.17d | 2009-03-13 | 2009-03-16 | 8 | 17.75d |  | start no earlier than 2009-02-20 | Project Team [66.7%]; Marketing [66.7%]; Sales Manager [66.7%] | 18.67h |
| 44 | 1.3.1.6 | Show signs and banners |  | 1.17d | 2009-03-13 | 2009-03-16 | 8 | 17.75d |  | start no earlier than 2009-02-20 | Project Team; Marketing | 18.67h |
| 45 | 1.3.1.7 | Booth and display centers |  | 2d | 2009-03-13 | 2009-03-17 | 8 | 16.92d |  | start no earlier than 2009-02-20 | Project Team; Marketing | 32h |
| 46 | 1.3.1.8 | Show staff attire |  | 1.17d | 2009-03-13 | 2009-03-16 | 8 | 17.75d |  | start no earlier than 2009-02-20 | Project Team; Marketing | 18.67h |
| 47 | 1.3.1.9 | WWW |  | 3.33d | 2009-03-13 | 2009-03-18 | 8 | 15.58d |  | start no earlier than 2009-02-20 | Project Team; Technical | 53.33h |
| 48 | 1.3.2 | **Risk Planning** |  | 1.17d | 2009-03-19 | 2009-03-20 | 33 | 50.83d |  |  |  |  |
| 49 | 1.3.2.1 | Materials contingency plan |  | 1.17d | 2009-03-19 | 2009-03-20 |  | 50.83d |  | start no earlier than 2009-02-20 |  |  |
| 50 | 1.3.3 | **Storage & Security requirements** |  | 1.08d | 2009-03-19 | 2009-03-20 | 33 | 50.92d |  |  |  | 18h |
| 51 | 1.3.3.1 | Define requirements |  | 0.58d | 2009-03-19 | 2009-03-20 |  | 51.42d |  | start no earlier than 2009-02-20 | Project Team | 4.67h |
| 52 | 1.3.3.2 | Review venue provisions |  | 0.58d | 2009-03-19 | 2009-03-20 |  | 51.42d |  | start no earlier than 2009-02-20 | Project Team | 4.67h |
| 53 | 1.3.3.3 | Obtain additional secured storage (if necessary) |  | 1.08d | 2009-03-19 | 2009-03-20 |  | 50.92d |  | start no earlier than 2009-02-20 | Project Team | 8.67h |

Notes:
- 37: Does the show promoter provide marketing materials? Or include the organization in show promotion materials for a fee?

| ID | WBS | Task | Type | Duration | Start | Finish | Predecessors | Total slack | Free slack | Constraint | Resources | Work |
| --- | --- | --- | --- | --- | --- | --- | --- | --- | --- | --- | --- | --- |
| 54 | 1.3.4 | **Keynote Speaker** |  | 2.33d | 2009-03-19 | 2009-03-24 | 33 | 49.67d |  |  |  | 60h |
| 55 | 1.3.4.1 | Identify potential keynotes |  | 1.33d | 2009-03-19 | 2009-03-23 |  | 50.67d |  | start no earlier than 2009-02-20 | Project Team | 10.67h |
| 56 | 1.3.4.2 | Meet with potential keynotes |  | 1.33d | 2009-03-19 | 2009-03-23 |  | 50.67d |  | start no earlier than 2009-02-20 | Project Team; Marketing | 21.33h |
| 57 | 1.3.4.3 | Select keynote |  | 0.58d | 2009-03-19 | 2009-03-20 |  | 51.42d |  | start no earlier than 2009-02-20 | Project Team; Marketing | 9.33h |
| 58 | 1.3.4.4 | Design keynote presentation |  | 2.33d | 2009-03-19 | 2009-03-24 |  | 49.67d |  | start no earlier than 2009-02-20 | Project Team [10%]; Marketing [50%]; Technical [40%] | 18.67h |
| 59 | 1.3.5 | **Design materials** |  | 9.17d | 2009-03-19 | 2009-04-01 | 33 | 14.75d | 0d |  |  | 74.67h |
| 60 | 1.3.5.1 | Brainstorming with design team |  | 1.17d | 2009-03-19 | 2009-03-20 |  | 14.75d | 0d | start no earlier than 2009-02-20 | Project Team; Marketing | 18.67h |
| 61 | 1.3.5.2 | Finalize materials design |  | 5d | 2009-03-20 | 2009-03-27 | 60 | 14.75d | 0d | start no earlier than 2009-02-20 | Marketing | 40h |
| 62 | 1.3.5.3 | Final design review |  | 2d | 2009-03-27 | 2009-03-31 | 61 | 14.75d | 0d |  | Project Team [50%]; Marketing [50%] | 16h |
| 63 | 1.3.5.4 | Sign-off on design | milestone | 0d | 2009-04-01 | 2009-04-01 | 62FS+1d | 14.75d | 0d |  | Marketing |  |
| 64 | 1.3.6 | **Order materials** |  | 8.92d | 2009-04-01 | 2009-04-14 | 59 | 14.75d | 1.17d |  |  | 71.33h |
| 65 | 1.3.6.1 | Purchase order |  | 1.17d | 2009-04-01 | 2009-04-03 |  | 14.75d | 0d | start no earlier than 2009-02-20 | Accounting | 9.33h |
| 66 | 1.3.6.2 | Materials shipping |  | 7.17d | 2009-04-03 | 2009-04-14 | 65 | 14.75d | 0d | start no earlier than 2009-02-20 | Vendors | 57.33h |
| 67 | 1.3.6.3 | Materials receipt by inventory control |  | 0.58d | 2009-04-14 | 2009-04-14 | 66 | 14.75d | 0d | start no earlier than 2009-02-20 | Inventory | 4.67h |
| 68 | 1.3.7 | **Review show vendor materials** |  | 3.58d | 2009-03-13 | 2009-03-19 | 8, 21 | 52.58d |  |  |  | 30h |
| 69 | 1.3.7.1 | Verify company logo used |  | 0.58d | 2009-03-13 | 2009-03-16 |  | 55.58d |  | start no earlier than 2009-02-20 | Marketing | 4.67h |
| 70 | 1.3.7.2 | Verify booth location information |  | 0.58d | 2009-03-13 | 2009-03-16 |  | 55.58d |  | start no earlier than 2009-02-20 | Marketing | 4.67h |
| 71 | 1.3.7.3 | Review company information |  | 0.58d | 2009-03-13 | 2009-03-16 |  | 52.58d | 0d | start no earlier than 2009-02-20 | Marketing | 4.67h |
| 72 | 1.3.7.4 | Final review show vendor materials |  | 2d | 2009-03-16 | 2009-03-18 | 71 | 52.58d | 0d |  | Marketing | 16h |
| 73 | 1.3.7.5 | Sign-off on show vendor materials | milestone | 0d | 2009-03-19 | 2009-03-19 | 72FS+1d | 52.58d |  | start no earlier than 2009-02-20 | Marketing |  |
| 74 | 1.3.8 | **Materials Asset Management** |  | 1.75d | 2009-04-14 | 2009-04-16 | 67 | 14.75d |  |  |  | 14h |
| 75 | 1.3.8.1 | Inventory of show materials |  | 1.17d | 2009-04-14 | 2009-04-15 |  | 14.75d | 0d | start no earlier than 2009-02-20 | Inventory | 9.33h |
| 76 | 1.3.8.2 | Insurance updates |  | 0.58d | 2009-04-16 | 2009-04-16 | 64, 75 | 32.17d |  | start no earlier than 2009-02-20 | Accounting | 4.67h |
| 77 | 1.3.9 | **Materials preparation & shipment** |  | 6.08d | 2009-04-16 | 2009-04-24 | 64, 75 | 14.75d | 0d |  |  | 48.67h |
| 78 | 1.3.9.1 | Package materials |  | 1.08d | 2009-04-16 | 2009-04-17 |  | 14.75d | 0d | start no earlier than 2009-02-20 | Inventory | 8.67h |
| 79 | 1.3.9.2 | Materials shipping to show location |  | 5d | 2009-04-17 | 2009-04-24 | 78 | 14.75d |  | start no earlier than 2009-02-20 | Inventory | 40h |

| ID | WBS | Task | Duration | Start | Finish | Predecessors | Total slack | Free slack | Constraint | Resources | Work |
| --- | --- | --- | --- | --- | --- | --- | --- | --- | --- | --- | --- |
| 81 | 1.4 | **Show Promotion** | 18.33d | 2009-03-13 | 2009-04-08 |  | 37.83d |  |  |  | 59.33h |
| 82 | 1.4.1 | Review show marketing plan | 0.58d | 2009-03-13 | 2009-03-16 | 8 | 55.58d |  | start no earlier than 2009-02-20 |  |  |
| 83 | 1.4.2 | Update company web site with show details | 3d | 2009-04-03 | 2009-04-08 | 63FS+2d | 37.83d |  | start no earlier than 2009-02-20 | Technical | 24h |
| 84 | 1.4.3 | Review competitor attendance | 0.58d | 2009-03-16 | 2009-03-17 | 38 | 54.5d |  | start no earlier than 2009-02-20 | Marketing | 4.67h |
| 85 | 1.4.4 | **Email customers, prospects** | 13.17d | 2009-03-13 | 2009-04-01 | 8, 27 | 43d |  |  |  | 18.67h |
| 86 | 1.4.4.1 | Initial email | 0.58d | 2009-03-13 | 2009-03-16 |  | 43d | 0d | start no earlier than 2009-02-20 | Sales Manager | 4.67h |
| 87 | 1.4.4.2 | Second email | 0.58d | 2009-04-01 | 2009-04-01 | 86FS+12d | 43d |  | start no earlier than 2009-02-20 | Sales Manager | 4.67h |
| 88 | 1.4.4.3 | Sales managers contact key clients & prospects | 1.17d | 2009-03-13 | 2009-03-16 |  | 55d |  | start no earlier than 2009-02-20 | Sales Manager | 9.33h |
| 89 | 1.4.5 | Press releases | 0.92d | 2009-03-13 | 2009-03-16 | 8, 27 | 55.25d |  | start no earlier than 2009-02-20 | Marketing | 7.33h |
| 90 | 1.4.6 | Notices in retail locations | 0.58d | 2009-03-13 | 2009-03-16 | 8, 27 | 55.58d |  | start no earlier than 2009-02-20 | Marketing | 4.67h |
| 92 | 1.5 | **Show Scheduling** | 0.58d | 2009-03-13 | 2009-03-16 | 8 | 55.58d |  |  |  | 18.67h |
| 93 | 1.5.1 | Special event schedule | 0.58d | 2009-03-13 | 2009-03-16 |  | 55.58d |  |  | Project Manager | 4.67h |
| 94 | 1.5.2 | Keynote schedule | 0.58d | 2009-03-13 | 2009-03-16 |  | 55.58d |  |  | Project Manager | 4.67h |
| 95 | 1.5.3 | Seminar schedule | 0.58d | 2009-03-13 | 2009-03-16 |  | 55.58d |  |  | Project Manager | 4.67h |
| 96 | 1.5.4 | Staff schedule | 0.58d | 2009-03-13 | 2009-03-16 | 99 | 55.58d |  |  | Project Manager | 4.67h |
| 98 | 1.6 | **Staff selection and training** | 47.75d | 2009-03-11 | 2009-05-16 |  | 10.58d |  |  |  | 29h |
| 99 | 1.6.1 | Staff selection | 1.08d | 2009-03-11 | 2009-03-12 | 11 | 56.08d | 0d | start no earlier than 2009-02-20 | Project Team | 8.67h |
| 100 | 1.6.2 | **Staff training** | 1.17d | 2009-05-15 | 2009-05-16 | 99 | 10.58d |  |  |  | 9.33h |
| 101 | 1.6.2.1 | Show objectives, agenda, schedule, etc. | 1.17d | 2009-05-15 | 2009-05-16 | 119FS-5d | 10.58d |  | start no earlier than 2009-02-20 | Project Team | 9.33h |
| 102 | 1.6.3 | Provide show attire | 1.08d | 2009-04-24 | 2009-04-27 | 77 | 25.58d |  |  | Project Team | 8.67h |
| 103 | 1.6.4 | Staff airline tickets | 0.58d | 2009-03-12 | 2009-03-13 | 99, 11 | 56.67d |  |  | Administrative [25%] | 1.17h |
| 104 | 1.6.5 | Staff hotel reservations | 0.58d | 2009-03-12 | 2009-03-13 | 99, 11 | 56.67d |  |  | Administrative [25%] | 1.17h |
| 106 | 1.7 | **Security** | 1.17d | 2009-04-01 | 2009-04-03 | 21, 59 | 41.67d |  |  |  | 9.33h |
| 107 | 1.7.1 | Review event security | 0.58d | 2009-04-01 | 2009-04-02 |  | 41.67d | 0d | start no earlier than 2009-02-20 | Project Team | 4.67h |
| 108 | 1.7.2 | Plan for storage of personal items | 0.58d | 2009-04-02 | 2009-04-03 | 107 | 41.67d |  |  | Project Team | 4.67h |

| ID | WBS | Task | Duration | Start | Finish | Predecessors | Total slack | Free slack | Constraint | Deadline | Resources | Work |
| --- | --- | --- | --- | --- | --- | --- | --- | --- | --- | --- | --- | --- |
| 110 | 1.8 | **Setup** | 2.17d | 2009-05-16 | 2009-05-18 | 77, 119FS-3d | -1.17d | 0d |  |  |  | 50h |
| 111 | 1.8.1 | Travel to location | 1.17d | 2009-05-17 | 2009-05-18 |  | -2.17d | 0d |  |  | Show Staff; Project Team | 18.67h |
| 112 | 1.8.2 | Review show manual | 0.25d | 2009-05-17 | 2009-05-17 |  | 9.5d |  |  |  | Show Staff; Project Team | 4h |
| 113 | 1.8.3 | **Booth** | 2d | 2009-05-16 | 2009-05-17 | 111, 77 | 0d |  |  | 2009-05-17 |  | 16h |
| 114 | 1.8.3.1 | Unpack and setup booth | 2d | 2009-05-16 | 2009-05-17 |  | -2.17d | 0d | must start on 2009-05-16 |  | Show Staff | 16h |
| 115 | 1.8.4 | **Materials** | 0.92d | 2009-05-17 | 2009-05-17 | 111, 77 | 0d |  |  | 2009-05-17 |  | 11.33h |
| 116 | 1.8.4.1 | Materials unpacking | 0.92d | 2009-05-17 | 2009-05-17 |  | -1.08d | 0d | must finish on 2009-05-17 |  | Show Staff | 7.33h |
| 117 | 1.8.4.2 | Materials inventory | 0.5d | 2009-05-17 | 2009-05-17 |  | -0.67d | 0d | must finish on 2009-05-17 |  | Show Staff | 4h |
| 119 | 1.9 | Show Day | 2d | 2009-05-18 | 2009-05-19 |  | -2.17d | 0d | start no earlier than 2009-05-18 |  | Show Staff | 16h |
| 121 | 1.10 | **Post Show** | 6.75d | 2009-05-20 | 2009-05-28 | 119 | 0d |  |  |  |  | 96h |
| 122 | 1.10.1 | **Tear down** | 6.75d | 2009-05-20 | 2009-05-28 |  | 0d |  |  |  |  | 58.67h |
| 123 | 1.10.1.1 | Pack booth | 1.17d | 2009-05-20 | 2009-05-21 |  | 0d |  | start no earlier than 2009-02-20 |  | Show Staff | 9.33h |
| 124 | 1.10.1.2 | Pack other show materials | 0.58d | 2009-05-20 | 2009-05-20 |  | 0.58d |  | start no earlier than 2009-02-20 |  | Show Staff | 4.67h |
| 125 | 1.10.1.3 | Materials shipping | 5d | 2009-05-21 | 2009-05-28 | 123, 124 | 0d |  | start no earlier than 2009-02-20 |  | Show Staff | 40h |
| 126 | 1.10.1.4 | Materials receiving / inventory | 0.58d | 2009-05-28 | 2009-05-28 | 125 | 0d |  | start no earlier than 2009-02-20 |  | Inventory | 4.67h |
| 127 | 1.10.2 | **Lead Review** | 1.17d | 2009-05-20 | 2009-05-21 |  | 5.58d |  |  |  |  | 28h |
| 128 | 1.10.2.1 | Sales database updates | 1.17d | 2009-05-20 | 2009-05-21 |  | 5.58d |  | start no earlier than 2009-02-20 |  | Technical | 9.33h |
| 129 | 1.10.2.2 | Lead qualification and distribution to sales staff | 1.17d | 2009-05-20 | 2009-05-21 |  | 5.58d |  | start no earlier than 2009-02-20 |  | Sales Manager | 9.33h |
| 130 | 1.10.2.3 | Email to show visitors | 0.58d | 2009-05-20 | 2009-05-20 |  | 6.17d |  | start no earlier than 2009-02-20 |  | Sales Manager | 4.67h |
| 131 | 1.10.2.4 | Direct mail / post additional requested information | 0.58d | 2009-05-20 | 2009-05-20 |  | 6.17d |  | start no earlier than 2009-02-20 |  | Sales Manager | 4.67h |
| 132 | 1.10.3 | **Project closing** | 0.58d | 2009-05-20 | 2009-05-20 |  | 6.17d |  |  |  |  | 9.33h |
| 133 | 1.10.3.1 | Project lessons learned | 0.58d | 2009-05-20 | 2009-05-20 |  | 6.17d |  | start no earlier than 2009-02-20 |  | Project Team | 4.67h |
| 134 | 1.10.3.2 | Budget amended to reflect final project costs | 0.58d | 2009-05-20 | 2009-05-20 |  | 6.17d |  | start no earlier than 2009-02-20 |  | Project Manager | 4.67h |
